# 3.0 Cronograma

Schedule from MS Project, 2026-05-08 to 2026-07-30, status date 2026-05-11.

## Calendars

- Estándar: Mon-Fri 09:00-13:00, 15:00-19:00; Sat-Sun off.

## Resources

| Resource | Unit | Rate |
| --- | --- | --- |
| Aceite quemado | gal | 0.6 |
| Acero de refuerzo fy=4200kg/cm2 | kg | 1.35 |
| Agua en m3 | m3 | 1.05 |
| Alambre galvanizado # 18 | kg | 2.36 |
| alfajias 0.04*0.04*2.40 m | u | 1.5 |
| Arena | m3 | 8 |
| Caña Guadua | m. | 0.37 |
| Cemento Portland | kg | 0.17 |
| Clavos 2 1/2" | kg | 1.7 |
| Encofrado para pozos hormigón | m. | 3 |
| Estacas (30 cm) | u | 0.35 |
| lastre | m3 | 3 |
| Lubricante | Lt | 1.1 |
| Piedra bola | m3 | 7.5 |
| Pintura anticorrosiva | gal | 18.46 |
| Pintura esmalte | gal | 18.25 |
| Ripio (3/4") - material triturado | m3 | 11 |
| Sumidero H.S. d=600 mm | u | 30 |
| sumidero rectang 600x300mm HD | u | 174.91 |
| Tabla de encofrado 0.30*2.40 m | u | 3.5 |
| tapa redonda HD 600mm | u | 261.33 |
| tiras (2.4x0.025x0.025) - Metros | m. | 0.37 |
| tubería PVC para alcantarillado di=200mm | m. | 15.97 |
| tubería PVC para alcantarillado di=250mm | m. | 19.76 |
| tubería PVC para alcantarillado di=350mm | m. | 47.72 |
| Albañil |  | 4.28 |
| Ayudante de Albañil |  | 4.23 |
| Ayudante de fierrero |  | 4.23 |
| Cadenero |  | 4.28 |
| Chofer profesional de volqueta |  | 6.22 |
| Encofrador o carpintero de ribera |  | 4.28 |
| Engrasador o abastecedor responsable |  | 4.28 |
| Fierrero |  | 4.28 |
| Maestro mayor en ejecucion de obras civiles |  | 4.75 |
| OPERADOR cargadora frontal |  | 4.75 |
| OPERADOR excavadora |  | 4.75 |
| OPERADOR Retroexcavadora |  | 4.75 |
| Peón |  | 4.23 |
| TOPOGRAFO (En Construcción) |  | 4.75 |
| Cargadora Frontal |  | 55 |
| Concretera 1 Saco |  | 6.5 |
| Cortadora de Hierro |  | 2.5 |
| excavadora(oruga) |  | 60 |
| Herramienta menor |  | 1 |
| Nivel |  | 1.5 |
| retroexcavadora (de llanta) |  | 30 |
| Teodolito |  | 1.5 |
| Vibrador |  | 3 |
| Vibro compactador(de plancha) |  | 4.25 |
| Volqueta 12m3 |  | 25 |
| Transporte |  |  |

## Schedule

| ID | WBS | Task | Type | Duration | Start | Finish | Predecessors | Resources |
| --- | --- | --- | --- | --- | --- | --- | --- | --- |
| 1 | 1 | **ALCANTARILLADO PLUVIAL CALLE COCHABAMBA** |  | 60d | 2026-05-08 | 2026-07-30 |  | Transporte |
| 2 | 1.1 | Replanteo y nivelación para redes hidrosanitarias. | manual | 2d | 2026-06-01 | 2026-06-02 |  |  |
| 3 | 1.2 | Excavación de suelo natural <2 m (a máquina). | manual | 6d | 2026-06-02 | 2026-06-09 | 2 |  |
| 4 | 1.3 | Excavación de suelo natural 2 a 4 m (a máquina). | manual | 4d | 2026-06-05 | 2026-06-10 | 3 |  |
| 5 | 1.4 | Rasanteo y preparación zanja (inc. Cama de arena). | manual | 8d | 2026-06-05 | 2026-06-16 | 2 |  |
| 6 | 1.5 | Sum/Ins/Tra Tubería PVC para alcantarillado dn=220mm. | manual | 3d | 2026-06-11 | 2026-06-15 | 3 |  |
| 7 | 1.6 | Sum/Ins/Tra Tubería PVC para alcantarillado dn=280mm. | manual | 1d | 2026-06-14 | 2026-06-14 | 4 |  |
| 8 | 1.7 | Sum/Ins/Tra Tubería PVC para alcantarillado dn=400mm. | manual | 6d | 2026-06-14 | 2026-06-19 | 4 |  |
| 9 | 1.8 | Relleno compactado con material de excavación. | manual | 6d | 2026-06-17 | 2026-06-24 | 8 |  |
| 10 | 1.9 | Relleno compactado con material lastre. | manual | 2d | 2026-06-25 | 2026-06-26 | 9 |  |
| 11 | 1.10 | Sub-base clase 3 tendido y compactado (maquina). | manual | 2d | 2026-06-29 | 2026-06-30 | 10 |  |
| 12 | 1.11 | Desalojo mecánico volqueta tierra/escombros. | manual | 1d | 2026-06-23 | 2026-06-23 |  |  |
| 13 | 1.12 | Pozo de Revisión H.S f`c=210kg/cm2 h=0-2m di=1m (el cuerpo). | manual | 3d | 2026-06-10 | 2026-06-12 | 3 |  |
| 14 | 1.13 | Pozo de Revisión H.S f`c=210kg/cm2 h=2-4m di=1m (el cuerpo). | manual | 8d | 2026-06-15 | 2026-06-24 | 13 |  |
| 15 | 1.14 | Pozo de Revisión H.S f`c=210kg/cm2 h=4-6m di=1m (el cuerpo). | manual | 1d | 2026-06-25 | 2026-06-25 | 14 |  |
| 16 | 1.15 | Sum/Ins/Tra Estribos de pozo de revisión d=16mm. | manual | 4d | 2026-07-02 | 2026-07-07 | 15 |  |
| 17 | 1.16 | Base H.C. del pozo de revisión d=1.50m e=0.30m. | manual | 2d | 2026-06-29 | 2026-06-30 | 4 |  |
| 18 | 1.17 | Losa de Tapa HA para pozo revisión e=0.20m d=1.40m. | manual | 5d | 2026-06-26 | 2026-07-02 | 15 |  |
| 19 | 1.18 | Sum/Ins/Tra Tapa Redonda HD 600mm. | manual | 3d | 2026-07-05 | 2026-07-07 | 18 |  |
| 20 | 1.19 | Sum/Ins/Tra Sumidero H.S. d=600 mm salida 200mm. | manual | 6d | 2026-06-23 | 2026-06-30 | 3 |  |
| 21 | 1.20 | Sum/Ins/Tra Rejilla Sumidero HD 600x300mm. | manual | 7d | 2026-07-02 | 2026-07-10 | 20 |  |
| 22 | 1.21 | Hormigón simple f`c=210 kg/cm2 con encofrado. | manual | 2d | 2026-07-08 | 2026-07-09 |  |  |
